# Obnova sekundarne opreme elektro – strojnega dela MHE Goričane po poplavi avgusta 2023

Schedule from MS Project, 2023-12-18 to 2024-09-30.
SEL d.o.o.

## Calendars

- Standardno: Mon-Fri 08:00-12:00, 13:00-17:00; Sat-Sun off.

## Schedule

| ID | WBS | Task | Type | Duration | Start | Finish | Predecessors | Total slack | Free slack | Constraint |
| --- | --- | --- | --- | --- | --- | --- | --- | --- | --- | --- |
| 1 | 1 | **Naročilo izvedbe** |  | 45d | 2023-12-18 | 2024-02-16 |  | -1d | 0d |  |
| 2 | 1.1 | **Izvedba JN** |  | 45d | 2023-12-18 | 2024-02-16 |  | -1d | 0d |  |
| 3 | 1.1.1 | Priprava |  | 5d | 2023-12-18 | 2023-12-22 |  | -1d | 0d | start no earlier than 2023-12-18 |
| 4 | 1.1.2 | Pregled | milestone | 0d | 2023-12-22 | 2023-12-22 | 3 | -1d | 0d |  |
| 5 | 1.1.3 | Objava razpisov | manual | 1d | 2023-12-22 | 2023-12-22 | 4 |  |  |  |
| 6 | 1.1.4 | Priprava ponudb ponudnikov |  | 28d | 2023-12-25 | 2024-01-31 | 5 | 0d |  |  |
| 7 | 1.1.5 | Odpiranje ponudb |  | 1d | 2024-02-01 | 2024-02-01 | 6 | 0d |  |  |
| 8 | 1.1.6 | Evalvacija pridobljenih ponudb |  | 5d | 2024-02-02 | 2024-02-08 | 7 | 0d |  |  |
| 9 | 1.1.7 | Priprava pogodbe |  | 5d | 2024-02-09 | 2024-02-15 | 8 | 0d |  |  |
| 10 | 1.1.8 | Podpis pogodb z izvajalci |  | 1d | 2024-02-16 | 2024-02-16 | 9 | 0d |  |  |
| 11 | 2 | **Izvedba** |  | 149d? | 2024-02-19 | 2024-09-12 | 1 | 0d |  |  |
| 12 | 2.1 | **Pripravljalna dela** |  | 4d | 2024-02-19 | 2024-02-22 |  | 0d |  |  |
| 13 | 2.1.1 | Priprava varnostne dokumentacije |  | 3d | 2024-02-19 | 2024-02-21 |  | 0d |  |  |
| 14 | 2.1.2 | Prijava gradbišča |  | 1d | 2024-02-22 | 2024-02-22 | 13 | 0d |  |  |
| 15 | 2.2 | Uvedba v delo |  | 1d | 2024-02-23 | 2024-02-23 | 14 | 84d | 0d |  |
| 16 | 2.3 | **PZI - Projekt za izvedbo** |  | 35d | 2024-02-23 | 2024-04-11 | 12 | 0d |  |  |
| 17 | 2.3.1 | Priprava |  | 30d | 2024-02-23 | 2024-04-04 |  | 0d |  |  |
| 18 | 2.3.2 | Pregled |  | 3d | 2024-04-05 | 2024-04-09 | 17 | 0d |  |  |
| 19 | 2.3.3 | Predstavitev in potrditev |  | 2d | 2024-04-10 | 2024-04-11 | 18 | 0d |  |  |
| 20 | 2.4 | Izdelava elektro omar |  | 50d | 2024-04-12 | 2024-06-20 | 19 | 0d |  |  |
| 21 | 2.5 | **Demontaža** |  | 20d | 2024-02-26 | 2024-03-22 | 15 | 84d | 64d |  |
| 22 | 2.5.1 | Demontaža in čiščenje turbinske opreme |  | 20d | 2024-02-26 | 2024-03-22 | 15 | 84d |  |  |
| 23 | 2.5.2 | Demontaža in čiščenje pomožnih sistemov |  | 20d | 2024-02-26 | 2024-03-22 | 15 | 84d |  |  |
| 24 | 2.5.3 | Demontaža in transport generatorja |  | 5d | 2024-02-26 | 2024-03-01 | 15 | 99d |  |  |

| ID | WBS | Task | Duration | Start | Finish | Predecessors | Total slack | Free slack |
| --- | --- | --- | --- | --- | --- | --- | --- | --- |
| 25 | 2.6 | **Montaža** | 20d | 2024-06-21 | 2024-07-18 | 16, 15, 20 | 0d |  |
| 26 | 2.6.1 | Montaža turbinske opreme | 20d | 2024-06-21 | 2024-07-18 | 21 | 20d |  |
| 27 | 2.6.2 | Montaža pomožnih sistemov | 20d | 2024-06-21 | 2024-07-18 | 21 | 20d |  |
| 28 | 2.6.3 | Montaža generatorja | 20d | 2024-06-21 | 2024-07-18 | 21 | 20d |  |
| 29 | 2.6.4 | Montaža hidromehanske opreme | 20d | 2024-06-21 | 2024-07-18 | 21 | 20d |  |
| 30 | 2.6.5 | Montaža elektro opreme | 15d | 2024-06-21 | 2024-07-11 | 20 | 0d |  |
| 31 | 2.7 | Spuščanje v obratovanje | 1d? | 2024-07-19 | 2024-07-19 | 25 | 20d | 4d |
| 32 | 2.8 | Preskušanje in testiranje opreme, zagonski preskusi | 10d | 2024-07-12 | 2024-07-25 | 30 | 0d |  |
| 33 | 2.9 | **PID - Projekt izvedenih del** | 19d | 2024-07-26 | 2024-08-21 | 25, 31, 32 | 16d |  |
| 34 | 2.9.1 | Priprava | 15d | 2024-07-26 | 2024-08-15 |  | 16d | 0d |
| 35 | 2.9.2 | Pregled | 3d | 2024-08-16 | 2024-08-20 | 34 | 16d | 0d |
| 36 | 2.9.3 | Predstavitev in potrditev | 1d | 2024-08-21 | 2024-08-21 | 35 | 16d |  |
| 37 | 2.10 | **NOV - Navodila za obratovanje in vzdrževanje** | 19d | 2024-07-26 | 2024-08-21 | 25, 31, 32 | 16d |  |
| 38 | 2.10.1 | Priprava | 15d | 2024-07-26 | 2024-08-15 |  | 16d | 0d |
| 39 | 2.10.2 | Pregled | 3d | 2024-08-16 | 2024-08-20 | 38 | 16d | 0d |
| 40 | 2.10.3 | Predstavitev in potrditev | 1d | 2024-08-21 | 2024-08-21 | 39 | 16d |  |
| 41 | 2.11 | **DZO - Dokazilo o zanesljivosti objekta** | 19d | 2024-07-26 | 2024-08-21 | 25, 31, 32 | 16d |  |
| 42 | 2.11.1 | Priprava | 15d | 2024-07-26 | 2024-08-15 |  | 16d | 0d |
| 43 | 2.11.2 | Pregled | 3d | 2024-08-16 | 2024-08-20 | 42 | 16d | 0d |
| 44 | 2.11.3 | Predstavitev in potrditev | 1d | 2024-08-21 | 2024-08-21 | 43 | 16d |  |
| 45 | 2.12 | **Interni tehnični pregled** | 4d | 2024-07-26 | 2024-07-31 | 32 | 0d |  |
| 46 | 2.12.1 | Priprava | 3d | 2024-07-26 | 2024-07-30 |  | 0d |  |
| 47 | 2.12.2 | Izvedba | 1d | 2024-07-31 | 2024-07-31 | 46 | 0d |  |
| 48 | 2.13 | **Poizkusno obratovanje** | 31d | 2024-08-01 | 2024-09-12 | 45 | 0d |  |
| 49 | 2.13.1 | Začetek poizkusnega obratovanja | 1d | 2024-08-01 | 2024-08-01 |  | 0d |  |
| 50 | 2.13.2 | Konec poizkusnega obratovanja | 30d | 2024-08-02 | 2024-09-12 | 49 | 0d |  |

| ID | WBS | Task | Duration | Start | Finish | Predecessors | Total slack |
| --- | --- | --- | --- | --- | --- | --- | --- |
| 51 | 3 | **Aktivacija** | 11d | 2024-09-13 | 2024-09-27 | 11, 33, 37, 41, 48 | 0d |
| 52 | 3.1 | Priprava in usklajevanje podlog | 10d | 2024-09-13 | 2024-09-26 |  | 0d |
| 53 | 3.2 | Podpis aktivacijskega zapisnika | 1d | 2024-09-27 | 2024-09-27 | 52 | 0d |
| 54 | 4 | Konec projekta | 1d | 2024-09-30 | 2024-09-30 | 51 | 0d |
